# SUBPROYECTO A3 - Presentado

Schedule from Primavera P6, 2024-10-16 to 2025-04-29, data date 2024-10-16.
Must finish by 2025-04-29

## Calendars

- 1T - 7x0 - 8 hr: Mon-Sun 08:00-16:00.

## Resources

| Resource | Group | Unit |
| --- | --- | --- |
| CAMION GRUA 20 TON | equipment |  |
| Grupo electrogeno | equipment |  |
| Motoniveladora 140K | equipment |  |
| Camion Cisterna | equipment |  |
| Rodillo Liso Vibratorio Autopropulsado 10-12 tn | equipment |  |
| TRACTOR SOBRE ORUGAS CAT D6D | equipment |  |
| EXCAVADORA CAT 336 | equipment |  |
| MARTILLO HIDRAULICO P/EXCAVADORA | equipment |  |
| mezcladora de concreto | equipment |  |
| Encofrado Recto | material | m3 |
| Tractor D8 | equipment |  |
| Excavacion en terreno natural con equipo | material | m3 |
| excavacion de uña con equipo | material | m3 |
| Motobomba 8" | equipment |  |
| Conformacion de cuerpo y corona de dique con mat. propio | material | m3 |
| Geotextil no tejido 400 gr/m2 | material |  |
| Camion grua 20 ton | equipment |  |
| Colocacion y acomodo de roca en uña | material | m3 |
| Colocacion y acomodo de roca en talud | material | m3 |
| Excavacion | material |  |
| RETROEXCAVADORA SOBRE LLANTAS 94 HP, 1.25 Y3 | equipment |  |
| RODILLO LISO VIBRATORIO MANUAL 10.8 HP 0.8 -1.1 Ton | equipment |  |
| Colocacion de concreto f'c=100 kg/cm2 | material | m3 |
| Colocacion de concreto f'c=280 kg/cm2 | material | m3 |
| Colocacion de concreto ciclopeo | material | m3 |
| armado de acero fy=4200 kg/cm2 | material | kg |
| Encofrado Curvo | material | m3 |
| Rodillo liso vibratorio 0.80 - 1.10 ton | equipment |  |

## Schedule

| ID | WBS | Activity | Type | Duration | Start | Finish | Predecessors | Total float | Free float | Resources |
| --- | --- | --- | --- | --- | --- | --- | --- | --- | --- | --- |
|  | 0 | **HITOS** |  |  | 2024-10-16 | 2025-04-29 |  |  |  |  |
| A1000 |  | KICK OFF MEETING | milestone | 0d | 2024-10-16 | 2024-10-16 |  | 0d |  |  |
| A1010 |  | INICIO DE PLAZO CONTRACTUAL - ACCESO AL SITIO | milestone | 0d | 2024-11-01 | 2024-11-01 | A1000 FS+16d | 1d | 0d |  |
| A1015 |  | INICIO DE EXCAVACIÓN | milestone | 0d | 2024-11-06 | 2024-11-06 | A1060 SS+5d, A1010 SS+5d | 1d | 0d |  |
| A1016 |  | INICIO DE RELLENO DE DIQUE | milestone | 0d | 2024-11-28 | 2024-11-28 | A1015 SS+22d | 5d | 0d |  |
| A1020 |  | FIN DE PLAZO CONTRACTUAL - CULMINACION DE OBRAS | milestone | 0d | 2025-04-29 | 2025-04-29 | A1780, A1070, A1050, A4020, A3850, A3790, A3780, A3740, A3730, A3470, A3450, A3140, A2930, A1900, A5010 FF, A5010 SF, A1890 FF, A1016 SF, A4430 FF, A5210 FF, A4960 FF, A4990 FF, A5610 FF, A5620 FF, A5740 FF, A4740 FF, A1080 FF | 0d |  |  |
|  | 1 | **DEFENSAS RIBEREÑAS** |  |  | 2024-10-16 | 2025-04-29 |  |  |  |  |
|  | 2 | **TRABAJOS PRELIMINARES** |  |  | 2024-10-16 | 2025-04-29 |  |  |  |  |
| A1060 |  | MOVILIZACION DE EQUIPOS |  | 16d | 2024-10-16 | 2024-10-31 | A1000 SS | 0d |  |  |
| A1070 |  | TOPOGRAFÍA Y GEOREFERENCIACIÓN |  | 175d | 2024-11-01 | 2025-04-24 | A1060 SS+2d, A1010 SS | 5d | 0d |  |
| A1080 |  | DESMOVILIZACION DE EQUIPOS |  | 5d | 2025-04-25 | 2025-04-29 | A5340, A1730 | 0d |  |  |
|  | 1 | **OBRAS PRELIMINARES** |  |  | 2024-11-01 | 2025-04-28 |  |  |  |  |
| A1030 |  | CARTEL DE IDENTIFICACIÓN OBRA 4.80 x 3.60 m. |  | 2d | 2024-11-01 | 2024-11-02 | A1060 SS+2d, A1010 SS | 4d | 3d | CAMION GRUA 20 TON [16 h] |
| A1040 |  | INSTALACIONES PROVISIONALES PARA LA OBRA |  | 169d | 2024-11-06 | 2025-04-23 | A1015, A1030 | 1d | 0d | Grupo electrogeno [1352 h] |
| A1050 |  | MANTENIMIENTO DE TRÁNSITO Y SEGURIDAD VIAL |  | 154d | 2024-11-26 | 2025-04-28 | A1100 | 1d |  | Motoniveladora 140K [616 h]; Camion Cisterna [1232 h]; Rodillo Liso Vibratorio Autopropulsado 10-12 tn [308 h] |
|  | 3 | **MEJORAMIENTO DE VÍAS EXISTENTES** |  |  | 2024-11-06 | 2025-01-06 |  |  |  |  |
|  | 1 | **MOVIMIENTO DE TIERRAS** |  |  | 2024-11-06 | 2024-11-25 |  |  |  |  |
| A1090 |  | ROCE Y LIMPIEZA DE MALEZA |  | 20d | 2024-11-06 | 2024-11-25 | A1015 SS, A1040 SS | 1d | 0d | TRACTOR SOBRE ORUGAS CAT D6D [160 h] |
| A1100 |  | MEJORAMIENTO DE VIAS EXISTENTES |  | 20d | 2024-11-06 | 2024-11-25 | A1090 SS | 1d | 0d | EXCAVADORA CAT 336 [80 h]; TRACTOR SOBRE ORUGAS CAT D6D [40 h]; Motoniveladora 140K [160 h]; Camion Cisterna [160 h]; Rodillo Liso Vibratorio Autopropulsado 10-12 tn [160 h] |
|  | 2 | **REPOSICIÓN DE ESTRUCTURAS** |  |  | 2024-11-26 | 2024-12-31 |  |  |  |  |
| A1150 |  | DEMOLICIÓN DE ESTRUCTURAS EXISTENTES |  | 2d | 2024-11-26 | 2024-11-27 | A1070 SS, A1100 | 35d | 0d | EXCAVADORA CAT 336 [16 h]; MARTILLO HIDRAULICO P/EXCAVADORA [16 h] |
| A1160 |  | REPOSICIÓN DE PASE DE AGUA TUBO HDPE Ø=18" |  | 2d | 2024-11-28 | 2024-11-29 | A1150 | 35d | 0d | CAMION GRUA 20 TON [16 h] |
| A1170 |  | REPOSICIÓN DE PASE DE AGUA TUBO HDPE Ø=36" |  | 2d | 2024-11-30 | 2024-12-01 | A1160 | 35d | 0d | CAMION GRUA 20 TON [16 h] |
| A1180 |  | SUMINISTRO Y MONTAJE DE PANELES DE C°A° 1.6mx1.0mx0.20m EN PASE DE AGUA |  | 30d | 2024-12-02 | 2024-12-31 | A1170 | 35d | 0d | CAMION GRUA 20 TON [240 h] |
| A1190 |  | SUMINISTRO Y MONTAJE DE PANELES DE C°A° 2.20mx1.0mx0.20m EN PASE DE AGUA |  | 30d | 2024-12-02 | 2024-12-31 | A1180 SS | 35d | 0d | CAMION GRUA 20 TON [240 h] |

| ID | WBS | Activity | Duration | Start | Finish | Predecessors | Total float | Free float | Resources | Filtro |
| --- | --- | --- | --- | --- | --- | --- | --- | --- | --- | --- |
|  | 4 | **CABEZAL DE ENTRADA Y SALIDA** |  | 2025-01-01 | 2025-01-06 |  |  |  |  |  |
| A1210 |  | ENCOFRADO Y DESENCOFRADO RECTO | 3d | 2025-01-01 | 2025-01-03 | A1190 | 35d | 0d | CAMION GRUA 20 TON [24 h]; Encofrado Recto [22 m3] |  |
| A1200 |  | CONCRETOS | 3d | 2025-01-04 | 2025-01-06 | A1210 | 35d | 7d | mezcladora de concreto [24 h] |  |
|  | 4 | **DESCOLMATACIÓN DE CAUCE Y OBRAS AUXILIARES** |  | 2024-11-01 | 2025-04-13 |  |  |  |  |  |
|  | 1 | **DESBROCE Y DESCOLMATACIÓN** |  | 2024-11-01 | 2025-02-05 |  |  |  |  |  |
| A5250 |  | DESBROCE Y LIMPIEZA INICIAL EN ZONA NO BOSCOSA | 4d | 2024-11-01 | 2024-11-04 | A1060 | 0d |  | EXCAVADORA CAT 336 [16 h]; TRACTOR SOBRE ORUGAS CAT D6D [32 h] | Excavación |
| A5260 |  | DESCOLMATACIÓN DE CAUCE NATURAL DEL RÍO LACRAMARCA - DIQUE A3-D-02 - INICIAL | 3d | 2024-11-05 | 2024-11-07 | A5250 | 0d |  | Tractor D8 [19.2 h] | Excavación |
| A1220 |  | DESBROCE Y LIMPIEZA EN ZONA NO BOSCOSA | 76d | 2024-11-06 | 2025-01-20 | A1015, A1010, A5250 | 2d | 0d | EXCAVADORA CAT 336 [608 h] | Excavación |
| A1230 |  | DESCOLMATACIÓN DE CAUCE NATURAL DEL RÍO LACRAMARCA - DIQUE A3-D-01 | 10d | 2024-11-08 | 2024-11-17 | A1220 SS+2d | 2d | 0d | Tractor D8 [64 h] | Excavación |
| A1880 |  | DESCOLMATACIÓN DE CAUCE NATURAL DEL RÍO LACRAMARCA - DIQUE A3-I-01 | 32d | 2024-11-12 | 2024-12-13 | A1220 SS+6d | 48d | 0d | Tractor D8 [204.8 h] | Excavación |
| A1870 |  | DESCOLMATACIÓN DE CAUCE NATURAL DEL RÍO LACRAMARCA - DIQUE A3-D-02 | 53d | 2024-11-18 | 2025-01-09 | A1230 | 12d | 8d | Tractor D8 [339.2 h] | Excavación |
| A1890 |  | DESCOLMATACIÓN DE CAUCE NATURAL DEL RÍO LACRAMARCA - DIQUE A3-I-02 | 20d | 2024-12-14 | 2025-01-02 | A1880 | 83d | 0d | Tractor D8 [128 h] | Excavación |
| A1900 |  | DESCOLMATACIÓN DE CAUCE NATURAL DEL RÍO LACRAMARCA - DIQUE A3-I-03 | 34d | 2025-01-03 | 2025-02-05 | A1890 | 83d |  | Tractor D8 [217.6 h] | Excavación |
|  | 2 | **DESVIO DEL CAUCE** |  | 2024-11-08 | 2025-04-13 |  |  |  |  |  |
| A5200 |  | CONFORMACIÓN DE DESVIO EN CAUCE DE RÍO | 68d | 2024-11-08 | 2025-01-14 | A1015 FS+2d, A5260 | 6d | 0d | TRACTOR SOBRE ORUGAS CAT D6D [544 h]; EXCAVADORA CAT 336 [17 h] |  |
| A5210 |  | RELLENO NO ESTRUCTURAL CON MATERIAL PROPIO | 89d | 2025-01-15 | 2025-04-13 | A5200 | 16d |  | TRACTOR SOBRE ORUGAS CAT D6D [712 h] |  |
|  | 5 | **DIQUES DE TIERRA COMPACTADA CON ENROCADO** |  | 2024-11-08 | 2025-04-24 |  |  |  |  |  |
|  | 1 | **DIQUE DE TIERRA COMPACTADA A3-D-01** |  | 2024-11-08 | 2024-12-07 |  |  |  |  |  |
|  | 1 | **CONSTRUCCION DIQUE A3-D-01** |  | 2024-11-08 | 2024-12-07 |  |  |  |  |  |
| A4210 |  | EXCAVACIÓN EN TERRENO NATURAL CON EQUIPO | 9d | 2024-11-08 | 2024-11-16 | A5250, A5260 | 0d |  | EXCAVADORA CAT 336 [72 h]; TRACTOR SOBRE ORUGAS CAT D6D [72 h]; Excavacion en terreno natural con equipo [6167 m3] | Excavación |
| A4230 |  | PERFILADO Y COMPACTACIÓN EN ZONA DE CORTE | 10d | 2024-11-09 | 2024-11-18 | A4210 SS+1d | 3d | 0d | EXCAVADORA CAT 336 [40 h] |  |
| A4240 |  | CONFORMACIÓN DE CUERPO DE DIQUE CON MATERIAL PROPIO | 5d | 2024-11-09 | 2024-11-13 | A4230 SS | 3d |  | TRACTOR SOBRE ORUGAS CAT D6D [40 h]; Conformacion de cuerpo y corona de dique con mat. propio [1319 m3]; Rodillo Liso Vibratorio Autopropulsado 10-12 tn [40 h] |  |
| A4220 |  | EXCAVACIÓN DE UÑA CON EQUIPO | 6d | 2024-11-12 | 2024-11-17 | A1230 SS+4d, A5200 SS | 2d |  | Motobomba 8" [38.4 h]; excavacion de uña con equipo [2325 m3]; EXCAVADORA CAT 336 [48 h] | Excavación |
| A4250 |  | CONFORMACIÓN DE CORONA DE DIQUE CON MATERIAL PROPIO | 5d | 2024-11-17 | 2024-11-21 | A4210, A4240 | 0d |  | TRACTOR SOBRE ORUGAS CAT D6D [40 h]; Rodillo Liso Vibratorio Autopropulsado 10-12 tn [40 h] | Relleno |
| A4260 |  | GEOTEXTIL NO TEJIDO 400 G/M2, INC. COLOCACIÓN | 6d | 2024-11-19 | 2024-11-24 | A4250 SS+2d | 0d |  | Camion grua 20 ton [38.4 h]; Geotextil no tejido 400 gr/m2 [5381] |  |
| A4270 |  | COLOCACION Y ACOMODO DE ROCA EN UÑA DE DIQUE | 6d | 2024-11-20 | 2024-11-25 | A4260 SS+1d, A4220 | 0d |  | TRACTOR SOBRE ORUGAS CAT D6D [12 h]; Colocacion y acomodo de roca en uña [2325 m3]; EXCAVADORA CAT 336 [96 h] | Roca |
| A4280 |  | COLOCACION Y ACOMODO DE ROCA EN TALUD DE DIQUE | 14d | 2024-11-22 | 2024-12-05 | A4270 SS+2d, A4210 | 0d |  | TRACTOR SOBRE ORUGAS CAT D6D [28 h]; Colocacion y acomodo de roca en talud [3493 m3]; EXCAVADORA CAT 336 [448 h] | Roca |
| A4290 |  | CONFORMACIÓN DE CORONA DE DIQUE CON MATERIAL PROPIO | 2d | 2024-12-06 | 2024-12-07 | A4280 | 0d |  | Motoniveladora 140K [16 h]; Rodillo Liso Vibratorio Autopropulsado 10-12 tn [16 h] | Relleno |

| ID | WBS | Activity | Duration | Start | Finish | Predecessors | Total float | Free float | Resources | Filtro |
| --- | --- | --- | --- | --- | --- | --- | --- | --- | --- | --- |
|  | 2 | **DIQUE DE TIERRA COMPACTADA A3-D-02** |  | 2024-11-26 | 2025-04-24 |  |  |  |  |  |
|  | 1 | **CONSTRUCCION DIQUE A3-D-02 TRAMO 1** |  | 2024-11-26 | 2025-01-10 |  |  |  |  |  |
| A4660 |  | EXCAVACIÓN EN TERRENO NATURAL CON EQUIPO | 11d | 2024-11-26 | 2024-12-06 | A5200 SS, A1870 SS, A1060, A4270 | 4d | 0d | Excavacion en terreno natural con equipo [13321 m3]; EXCAVADORA CAT 336 [176 h]; TRACTOR SOBRE ORUGAS CAT D6D [44 h] | Excavación |
| A4680 |  | PERFILADO Y COMPACTACIÓN EN ZONA DE CORTE | 14d | 2024-11-27 | 2024-12-10 | A4660 SS+1d | 13d | 0d |  |  |
| A4690 |  | CONFORMACIÓN DE CUERPO DE DIQUE CON MATERIAL PROPIO | 7d | 2024-12-03 | 2024-12-09 | A4680 SS+6d | 13d |  | Conformacion de cuerpo y corona de dique con mat. propio [2997 m3]; TRACTOR SOBRE ORUGAS CAT D6D [56 h]; Motoniveladora 140K [56 h]; Rodillo Liso Vibratorio Autopropulsado 10-12 tn [56 h] |  |
| A4700 |  | CONFORMACIÓN DE CORONADE DIQUE CON MATERIAL PROPIO | 5d | 2024-12-07 | 2024-12-11 | A4660 | 8d | 0d | TRACTOR SOBRE ORUGAS CAT D6D [40 h]; Rodillo Liso Vibratorio Autopropulsado 10-12 tn [40 h] | Relleno |
| A4670 |  | EXCAVACIÓN DE UÑA CON EQUIPO | 10d | 2024-12-08 | 2024-12-17 | A1060, A1015 SS, A5260, A4280, A4290 | 0d |  | excavacion de uña con equipo [4179 m3]; EXCAVADORA CAT 336 [80 h]; Motobomba 8" [64 h] | Excavación |
| A4710 |  | GEOTEXTIL NO TEJIDO 400 G/M2, INC. COLOCACIÓN | 6d | 2024-12-09 | 2024-12-14 | A4700 SS+2d | 8d |  | Geotextil no tejido 400 gr/m2 [6091]; CAMION GRUA 20 TON [48 h] |  |
| A4720 |  | COLOCACION Y ACOMODO DE ROCA EN UÑA DE DIQUE | 22d | 2024-12-18 | 2025-01-08 | A4670 | 0d |  | Colocacion y acomodo de roca en uña [4179 m3]; EXCAVADORA CAT 336 [176 h]; TRACTOR SOBRE ORUGAS CAT D6D [88 h] | Roca |
| A4730 |  | COLOCACION Y ACOMODO DE ROCA EN TALUD DE DIQUE | 19d | 2024-12-23 | 2025-01-10 | A4720 SS+5d, A4690, A4710 | 0d |  | Colocacion y acomodo de roca en talud [5005 m3]; EXCAVADORA CAT 336 [608 h]; TRACTOR SOBRE ORUGAS CAT D6D [76 h] | Roca |
| A4740 |  | CONFORMACIÓN DE CORONA DE DIQUE CON MATERIAL PROPIO | 2d | 2025-01-09 | 2025-01-10 | A4730 FF | 109d |  |  | Relleno |
|  | 4 | **CONSTRUCCION DIQUE A3-D-02 TRAMO 2** |  | 2025-01-09 | 2025-02-13 |  |  |  |  |  |
| A5450 |  | EXCAVACIÓN EN TERRENO NATURAL CON EQUIPO | 11d | 2025-01-09 | 2025-01-19 | A4720 | 4d | 0d | Excavacion en terreno natural con equipo [13321 m3]; EXCAVADORA CAT 336 [176 h]; TRACTOR SOBRE ORUGAS CAT D6D [44 h] | Excavación |
| A5470 |  | PERFILADO Y COMPACTACIÓN EN ZONA DE CORTE | 14d | 2025-01-09 | 2025-01-22 | A5450 SS | 4d | 0d | EXCAVADORA CAT 336 [112 h] |  |
| A5460 |  | EXCAVACIÓN DE UÑA CON EQUIPO | 10d | 2025-01-11 | 2025-01-20 | A4730 | 0d |  | excavacion de uña con equipo [4179 m3]; EXCAVADORA CAT 336 [80 h]; Motobomba 8" [64 h] | Excavación |
| A5530 |  | PREPARACIÓN DE FUNDACIÓN DE CUERPO DE DIQUE | 7d | 2025-01-15 | 2025-01-21 | A5470 SS+6d | 4d |  | Motoniveladora 140K [56 h]; Rodillo Liso Vibratorio Autopropulsado 10-12 tn [56 h] |  |
| A5480 |  | CONFORMACIÓN DE CUERPO Y CORONA DE DIQUE CON MATERIAL PROPIO | 12d | 2025-01-19 | 2025-01-30 | A5460 SS+8d | 0d |  | Conformacion de cuerpo y corona de dique con mat. propio [2997 m3]; TRACTOR SOBRE ORUGAS CAT D6D [96 h]; Rodillo Liso Vibratorio Autopropulsado 10-12 tn [96 h] | Relleno |
| A5500 |  | GEOTEXTIL NO TEJIDO 400 G/M2, INC. COLOCACIÓN | 6d | 2025-01-21 | 2025-01-26 | A5480 SS+2d | 0d |  | Geotextil no tejido 400 gr/m2 [6091]; CAMION GRUA 20 TON [48 h] |  |
| A5510 |  | COLOCACION Y ACOMODO DE ROCA EN UÑA DE DIQUE | 22d | 2025-01-21 | 2025-02-11 | A5500 SS, A5460 | 0d |  | Colocacion y acomodo de roca en uña [4179 m3]; EXCAVADORA CAT 336 [176 h]; TRACTOR SOBRE ORUGAS CAT D6D [44 h] | Roca |
| A5520 |  | COLOCACION Y ACOMODO DE ROCA EN TALUD DE DIQUE | 19d | 2025-01-26 | 2025-02-13 | A5510 SS+5d, A5530 | 0d |  | Colocacion y acomodo de roca en talud [5005 m3]; EXCAVADORA CAT 336 [608 h]; TRACTOR SOBRE ORUGAS CAT D6D [38 h] | Roca |
|  | 3 | **CONSTRUCCION DIQUE A3-D-02 TRAMO 3** |  | 2025-02-12 | 2025-03-20 |  |  |  |  |  |
| A5360 |  | EXCAVACIÓN EN TERRENO NATURAL CON EQUIPO | 11d | 2025-02-12 | 2025-02-22 | A5510 | 9d | 0d | Excavacion en terreno natural con equipo [13321 m3]; EXCAVADORA CAT 336 [1408 h] | Excavación |
| A5380 |  | PERFILADO Y COMPACTACIÓN EN ZONA DE CORTE | 14d | 2025-02-13 | 2025-02-26 | A5360 SS+1d | 9d | 0d | EXCAVADORA CAT 336 [56 h] |  |
| A5370 |  | EXCAVACIÓN DE UÑA CON EQUIPO | 10d | 2025-02-14 | 2025-02-23 | A5520 | 0d |  | excavacion de uña con equipo [4179 m3]; EXCAVADORA CAT 336 [80 h] | Excavación |
| A5440 |  | PREPARACIÓN DE FUNDACIÓN DE CUERPO DE DIQUE | 2d | 2025-02-19 | 2025-02-20 | A5380 SS+6d | 9d |  |  |  |
| A5390 |  | CONFORMACIÓN DE CUERPO Y CORONA DE DIQUE CON MATERIAL PROPIO | 5d | 2025-02-22 | 2025-02-26 | A5370 SS+8d | 0d |  | Conformacion de cuerpo y corona de dique con mat. propio [2997 m3] | Relleno |
| A5410 |  | GEOTEXTIL NO TEJIDO 400 G/M2, INC. COLOCACIÓN | 6d | 2025-02-24 | 2025-03-01 | A5390 SS+2d | 0d |  | Geotextil no tejido 400 gr/m2 [6091] |  |
| A5420 |  | COLOCACION Y ACOMODO DE ROCA EN UÑA DE DIQUE | 22d | 2025-02-25 | 2025-03-18 | A5410 SS+1d, A5370 | 0d |  | Colocacion y acomodo de roca en uña [4179 m3]; EXCAVADORA CAT 336 [176 h] | Roca |
| A5430 |  | COLOCACION Y ACOMODO DE ROCA EN TALUD DE DIQUE | 19d | 2025-03-02 | 2025-03-20 | A5420 SS+5d, A5440 | 0d |  | Colocacion y acomodo de roca en talud [5005 m3]; EXCAVADORA CAT 336 [608 h] | Roca |

| ID | WBS | Activity | Duration | Start | Finish | Predecessors | Total float | Free float | Resources | Filtro |
| --- | --- | --- | --- | --- | --- | --- | --- | --- | --- | --- |
|  | 2 | **CONSTRUCCION DIQUE A3-D-02 TRAMO 4** |  | 2025-03-19 | 2025-04-24 |  |  |  |  |  |
| A5270 |  | EXCAVACIÓN EN TERRENO NATURAL CON EQUIPO | 11d | 2025-03-19 | 2025-03-29 | A5420 | 9d | 0d | Excavacion en terreno natural con equipo [13321 m3]; TRACTOR SOBRE ORUGAS CAT D6D [44 h] | Excavación |
| A5290 |  | PERFILADO Y COMPACTACIÓN EN ZONA DE CORTE | 14d | 2025-03-20 | 2025-04-02 | A5270 SS+1d | 9d | 0d | Motobomba 8" [89.6 h] |  |
| A5280 |  | EXCAVACIÓN DE UÑA CON EQUIPO | 10d | 2025-03-21 | 2025-03-30 | A5430 | 0d |  | excavacion de uña con equipo [4179 m3] | Excavación |
| A5350 |  | PREPARACIÓN DE FUNDACIÓN DE CUERPO DE DIQUE | 2d | 2025-03-26 | 2025-03-27 | A5290 SS+6d | 9d |  | Motoniveladora 140K [16 h]; Rodillo Liso Vibratorio Autopropulsado 10-12 tn [16 h] |  |
| A5300 |  | CONFORMACIÓN DE CUERPO Y CORONA DE DIQUE CON MATERIAL PROPIO | 5d | 2025-03-29 | 2025-04-02 | A5280 SS+8d | 0d |  | Conformacion de cuerpo y corona de dique con mat. propio [2997 m3]; TRACTOR SOBRE ORUGAS CAT D6D [40 h]; Rodillo Liso Vibratorio Autopropulsado 10-12 tn [40 h] | Relleno |
| A5320 |  | GEOTEXTIL NO TEJIDO 400 G/M2, INC. COLOCACIÓN | 6d | 2025-03-31 | 2025-04-05 | A5300 SS+2d | 0d |  | Geotextil no tejido 400 gr/m2 [6091]; Camion grua 20 ton [38.4 h] |  |
| A5330 |  | COLOCACION Y ACOMODO DE ROCA EN UÑA DE DIQUE | 22d | 2025-04-01 | 2025-04-22 | A5320 SS+1d, A5280 | 0d |  | Colocacion y acomodo de roca en uña [4179 m3]; TRACTOR SOBRE ORUGAS CAT D6D [44 h] | Roca |
| A5340 |  | COLOCACION Y ACOMODO DE ROCA EN TALUD DE DIQUE | 19d | 2025-04-06 | 2025-04-24 | A5330 SS+5d, A5350 | 0d |  | Colocacion y acomodo de roca en talud [5005 m3]; TRACTOR SOBRE ORUGAS CAT D6D [38 h] | Roca |
|  | 3 | **DIQUE DE TIERRA COMPACTADA A3-I-01** |  | 2024-11-08 | 2024-12-16 |  |  |  |  |  |
|  | 1 | **CONSTRUCCION DIQUE A3-I-01** |  | 2024-11-08 | 2024-12-16 |  |  |  |  |  |
| A1440 |  | EXCAVACIÓN EN TERRENO NATURAL CON EQUIPO | 11d | 2024-11-08 | 2024-11-18 | A1230 SS, A1015 SS | 7d | 0d | Excavacion en terreno natural con equipo [13764 m3]; EXCAVADORA CAT 336 [176 h]; TRACTOR SOBRE ORUGAS CAT D6D [44 h] | Excavación |
| A1450 |  | EXCAVACIÓN DE UÑA CON EQUIPO | 5d | 2024-11-22 | 2024-11-26 | A1440 FS+3d | 7d | 0d | excavacion de uña con equipo [2275 m3]; EXCAVADORA CAT 336 [40 h]; Motobomba 8" [32 h] | Excavación |
| A1460 |  | PERFILADO Y COMPACTACIÓN EN ZONA DE CORTE | 8d | 2024-11-22 | 2024-11-29 | A1440 SS+1d, A1450 SS | 7d | 0d | EXCAVADORA CAT 336 [256 h] |  |
| A1520 |  | PREPARACIÓN DE FUNDACIÓN DE CUERPO DE DIQUE | 2d | 2024-11-25 | 2024-11-26 | A1460 SS+3d | 7d | 2d | Motoniveladora 140K [16 h]; Rodillo Liso Vibratorio Autopropulsado 10-12 tn [16 h] |  |
| A1470 |  | CONFORMACIÓN DE CUERPO Y CORONA DE DIQUE CON MATERIAL PROPIO | 8d | 2024-11-28 | 2024-12-05 | A1520 SS+1d, A1016 SS | 5d | 0d | Conformacion de cuerpo y corona de dique con mat. propio [3772 m3]; TRACTOR SOBRE ORUGAS CAT D6D [64 h]; Rodillo Liso Vibratorio Autopropulsado 10-12 tn [64 h] | Relleno |
| A1490 |  | GEOTEXTIL NO TEJIDO 400 G/M2, INC. COLOCACIÓN | 5d | 2024-11-30 | 2024-12-04 | A1470 SS+2d | 5d | 0d | Geotextil no tejido 400 gr/m2 [5276]; Camion grua 20 ton [32 h] |  |
| A1500 |  | COLOCACION Y ACOMODO DE ROCA EN UÑA DE DIQUE | 6d | 2024-12-01 | 2024-12-06 | A1490 SS+1d, A1450 | 5d | 0d | Colocacion y acomodo de roca en uña [2275 m3]; EXCAVADORA CAT 336 [48 h]; TRACTOR SOBRE ORUGAS CAT D6D [24 h] | Roca |
| A1510 |  | COLOCACION Y ACOMODO DE ROCA EN TALUD DE DIQUE | 12d | 2024-12-03 | 2024-12-14 | A1500 SS+2d, A1440 | 5d | 0d | Colocacion y acomodo de roca en talud [3426 m3]; EXCAVADORA CAT 336 [384 h]; TRACTOR SOBRE ORUGAS CAT D6D [48 h] | Roca |
| A1480 |  | CONFORMACIÓN DE CORONA DE DIQUE CON MATERIAL PROPIO | 5d | 2024-12-12 | 2024-12-16 | A1510 FF+2d | 5d | 0d |  | Relleno |
|  | 4 | **DIQUE DE TIERRA COMPACTADA A3-I-02** |  | 2024-12-17 | 2025-01-16 |  |  |  |  |  |
|  | 2 | **CONSTRUCCION DIQUE A3-I-02** |  | 2024-12-17 | 2025-01-16 |  |  |  |  |  |
| A4390 |  | EXCAVACIÓN EN TERRENO NATURAL CON EQUIPO | 15d | 2024-12-17 | 2024-12-31 | A1520, A1510, A1480 | 5d | 0d | Excavacion en terreno natural con equipo [18781 m3]; EXCAVADORA CAT 336 [240 h]; TRACTOR SOBRE ORUGAS CAT D6D [120 h] | Excavación |
| A4400 |  | EXCAVACIÓN DE UÑA CON EQUIPO | 7d | 2024-12-18 | 2024-12-24 | A4390 SS+1d | 12d | 7d | excavacion de uña con equipo [3101 m3]; EXCAVADORA CAT 336 [56 h]; Motobomba 8" [44.8 h] | Excavación |
| A4410 |  | PERFILADO Y COMPACTACIÓN EN ZONA DE CORTE | 11d | 2024-12-20 | 2024-12-30 | A4390 SS+3d | 5d | 0d |  |  |
| A4470 |  | PREPARACIÓN DE FUNDACIÓN DE CUERPO DE DIQUE | 1d | 2024-12-31 | 2024-12-31 | A4410 FF+1d | 5d | 0d | Motoniveladora 140K [8 h]; Rodillo Liso Vibratorio Autopropulsado 10-12 tn [8 h] |  |
| A4420 |  | CONFORMACIÓN DE CUERPO Y CORONA DE DIQUE CON MATERIAL PROPIO | 2d | 2025-01-01 | 2025-01-02 | A4470 SS+1d, A4400 | 5d | 0d | Conformacion de cuerpo y corona de dique con mat. propio [1739 m3]; TRACTOR SOBRE ORUGAS CAT D6D [16 h]; Rodillo Liso Vibratorio Autopropulsado 10-12 tn [16 h] | Relleno |
| A4440 |  | GEOTEXTIL NO TEJIDO 400 G/M2, INC. COLOCACIÓN | 5d | 2025-01-01 | 2025-01-05 | A4420 SS, A4410 | 9d | 0d | Geotextil no tejido 400 gr/m2 [4752]; CAMION GRUA 20 TON [40 h] |  |
| A4450 |  | COLOCACION Y ACOMODO DE ROCA EN UÑA DE DIQUE | 16d | 2025-01-01 | 2025-01-16 | A4440 SS | 9d | 0d | Colocacion y acomodo de roca en uña [3101 m3]; EXCAVADORA CAT 336 [128 h]; TRACTOR SOBRE ORUGAS CAT D6D [32 h] | Roca |
| A4460 |  | COLOCACION Y ACOMODO DE ROCA EN TALUD DE DIQUE | 14d | 2025-01-01 | 2025-01-14 | A4450 SS | 9d | 0d | Colocacion y acomodo de roca en talud [3837 m3]; EXCAVADORA CAT 336 [448 h]; TRACTOR SOBRE ORUGAS CAT D6D [56 h] | Roca |
| A4430 |  | CONFORMACIÓN DE CORONA DE DIQUE CON MATERIAL PROPIO | 6d | 2025-01-10 | 2025-01-15 | A4460 FF+1d | 26d | 0d |  | Relleno |

| ID | WBS | Activity | Duration | Start | Finish | Predecessors | Total float | Free float | Resources | Filtro |
| --- | --- | --- | --- | --- | --- | --- | --- | --- | --- | --- |
|  | 5 | **DIQUE DE TIERRA COMPACTADA A3-I-03** |  | 2025-01-15 | 2025-04-20 |  |  |  |  |  |
|  | 1 | **CONSTRUCCION DIQUE A3-I-03 TRAMO 1** |  | 2025-01-15 | 2025-02-16 |  |  |  |  |  |
| A4930 |  | EXCAVACIÓN EN TERRENO NATURAL CON EQUIPO | 9d | 2025-01-15 | 2025-01-23 | A4460 | 9d | 0d | Excavacion en terreno natural con equipo [11506 m3]; EXCAVADORA CAT 336 [144 h]; TRACTOR SOBRE ORUGAS CAT D6D [72 h] | Excavación |
| A4950 |  | PERFILADO Y COMPACTACIÓN EN ZONA DE CORTE | 16d | 2025-01-16 | 2025-01-31 | A4930 SS+1d, A4430 | 26d | 0d | Motobomba 8" [102.4 h] |  |
| A4940 |  | EXCAVACIÓN DE UÑA CON EQUIPO | 10d | 2025-01-17 | 2025-01-26 | A4450 | 10d | 0d | excavacion de uña con equipo [4593 m3]; EXCAVADORA CAT 336 [80 h] | Excavación |
| A4970 |  | CONFORMACIÓN DE CUERPO Y CORONA DE DIQUE CON MATERIAL PROPIO | 8d | 2025-01-19 | 2025-01-26 | A4940 SS+2d | 12d | 0d | Conformacion de cuerpo y corona de dique con mat. propio [3253 m3]; TRACTOR SOBRE ORUGAS CAT D6D [64 h]; Rodillo Liso Vibratorio Autopropulsado 10-12 tn [64 h] | Relleno |
| A4980 |  | GEOTEXTIL NO TEJIDO 400 G/M2, INC. COLOCACIÓN | 7d | 2025-01-21 | 2025-01-27 | A4970 SS+2d | 12d | 3d | Geotextil no tejido 400 gr/m2 [6607]; CAMION GRUA 20 TON [56 h] |  |
| A4990 |  | COLOCACION Y ACOMODO DE ROCA EN UÑA DE DIQUE | 23d | 2025-01-24 | 2025-02-15 | A4980 SS, A4930 | 9d | 0d | Colocacion y acomodo de roca en uña [4593 m3]; EXCAVADORA CAT 336 [184 h]; TRACTOR SOBRE ORUGAS CAT D6D [46 h] | Roca |
| A5000 |  | COLOCACION Y ACOMODO DE ROCA EN TALUD DE DIQUE | 21d | 2025-01-27 | 2025-02-16 | A4990 SS+1d, A4940 | 10d | 0d | Colocacion y acomodo de roca en talud [5548 m3]; EXCAVADORA CAT 336 [672 h]; TRACTOR SOBRE ORUGAS CAT D6D [84 h] | Roca |
| A4960 |  | PREPARACIÓN DE FUNDACIÓN DE CUERPO DE DIQUE | 5d | 2025-02-01 | 2025-02-05 | A4950 SS+16d | 26d | 12d | Motoniveladora 140K [40 h]; Rodillo Liso Vibratorio Autopropulsado 10-12 tn [40 h] |  |
| A5010 |  | CONFORMACIÓN DE CORONA DE DIQUE CON MATERIAL PROPIO | 2d | 2025-02-15 | 2025-02-16 | A5000 FF | 72d |  |  | Relleno |
|  | 3 | **CONSTRUCCION DIQUE A3-I-03 TRAMO 2** |  | 2025-02-16 | 2025-03-19 |  |  |  |  |  |
| A5630 |  | EXCAVACIÓN EN TERRENO NATURAL CON EQUIPO | 9d | 2025-02-16 | 2025-02-24 | A4990 | 9d | 0d | Excavacion en terreno natural con equipo [11506 m3]; EXCAVADORA CAT 336 [144 h]; TRACTOR SOBRE ORUGAS CAT D6D [72 h] | Excavación |
| A5650 |  | PERFILADO Y COMPACTACIÓN EN ZONA DE CORTE | 16d | 2025-02-16 | 2025-03-03 | A5630 SS | 35d | 0d |  |  |
| A5640 |  | EXCAVACIÓN DE UÑA CON EQUIPO | 10d | 2025-02-17 | 2025-02-26 | A5000 | 10d | 0d | excavacion de uña con equipo [4593 m3]; EXCAVADORA CAT 336 [80 h]; Motobomba 8" [80 h] | Excavación |
| A5660 |  | CONFORMACIÓN DE CUERPO Y CORONA DE DIQUE CON MATERIAL PROPIO | 5d | 2025-02-18 | 2025-02-22 | A5640 SS+1d, A4960 | 14d | 0d | Conformacion de cuerpo y corona de dique con mat. propio [3253 m3]; TRACTOR SOBRE ORUGAS CAT D6D [40 h]; Rodillo Liso Vibratorio Autopropulsado 10-12 tn [40 h] | Relleno |
| A5680 |  | GEOTEXTIL NO TEJIDO 400 G/M2, INC. COLOCACIÓN | 7d | 2025-02-20 | 2025-02-26 | A5660 SS+2d | 14d | 5d | Geotextil no tejido 400 gr/m2 [6607]; CAMION GRUA 20 TON [56 h] |  |
| A5710 |  | PREPARACIÓN DE FUNDACIÓN DE CUERPO DE DIQUE | 2d | 2025-02-21 | 2025-02-22 | A5650 SS+5d | 35d | 25d | Motoniveladora 140K [12.8 h]; Rodillo Liso Vibratorio Autopropulsado 10-12 tn [16 h] |  |
| A5690 |  | COLOCACION Y ACOMODO DE ROCA EN UÑA DE DIQUE | 23d | 2025-02-25 | 2025-03-19 | A5680 SS, A5630 | 9d | 0d | Colocacion y acomodo de roca en uña [4593 m3]; EXCAVADORA CAT 336 [184 h]; TRACTOR SOBRE ORUGAS CAT D6D [92 h] | Roca |
| A5700 |  | COLOCACION Y ACOMODO DE ROCA EN TALUD DE DIQUE | 21d | 2025-02-27 | 2025-03-19 | A5690 SS+1d, A5640 | 10d | 0d | Colocacion y acomodo de roca en talud [5548 m3]; EXCAVADORA CAT 336 [672 h]; TRACTOR SOBRE ORUGAS CAT D6D [168 h] | Roca |
|  | 2 | **CONSTRUCCION DIQUE A3-I-03 TRAMO 3** |  | 2025-03-20 | 2025-04-20 |  |  |  |  |  |
| A5540 |  | EXCAVACIÓN EN TERRENO NATURAL CON EQUIPO | 9d | 2025-03-20 | 2025-03-28 | A5690 | 9d | 0d | Excavacion en terreno natural con equipo [11506 m3]; EXCAVADORA CAT 336 [144 h]; TRACTOR SOBRE ORUGAS CAT D6D [36 h] | Excavación |
| A5550 |  | EXCAVACIÓN DE UÑA CON EQUIPO | 10d | 2025-03-20 | 2025-03-29 | A5540 SS, A5700, A5710 | 10d | 0d | excavacion de uña con equipo [4593 m3]; EXCAVADORA CAT 336 [80 h]; Motobomba 8" [80 h] | Excavación |
| A5560 |  | PERFILADO Y COMPACTACIÓN EN ZONA DE CORTE | 16d | 2025-03-20 | 2025-04-04 | A5540 SS | 23d | 0d |  |  |
| A5570 |  | CONFORMACIÓN DE CUERPO Y CORONA DE DIQUE CON MATERIAL PROPIO | 5d | 2025-03-21 | 2025-03-25 | A5550 SS+1d | 15d | 0d | Conformacion de cuerpo y corona de dique con mat. propio [3253 m3]; TRACTOR SOBRE ORUGAS CAT D6D [40 h]; Rodillo Liso Vibratorio Autopropulsado 10-12 tn [40 h] | Relleno |
| A5590 |  | GEOTEXTIL NO TEJIDO 400 G/M2, INC. COLOCACIÓN | 7d | 2025-03-23 | 2025-03-29 | A5570 SS+2d | 15d | 6d | Geotextil no tejido 400 gr/m2 [6607]; Camion grua 20 ton [56 h] |  |
| A5600 |  | COLOCACION Y ACOMODO DE ROCA EN UÑA DE DIQUE | 23d | 2025-03-29 | 2025-04-20 | A5590 SS, A5540 | 9d | 0d | Colocacion y acomodo de roca en uña [4593 m3]; EXCAVADORA CAT 336 [184 h]; TRACTOR SOBRE ORUGAS CAT D6D [46 h] | Roca |
| A5610 |  | COLOCACION Y ACOMODO DE ROCA EN TALUD DE DIQUE | 21d | 2025-03-30 | 2025-04-19 | A5600 SS+1d, A5550 | 10d |  | Colocacion y acomodo de roca en talud [5548 m3]; EXCAVADORA CAT 336 [672 h]; TRACTOR SOBRE ORUGAS CAT D6D [84 h] | Roca |
| A5620 |  | PREPARACIÓN DE FUNDACIÓN DE CUERPO DE DIQUE | 2d | 2025-04-05 | 2025-04-06 | A5560 SS+16d | 23d |  | Motoniveladora 140K [16 h]; Rodillo Liso Vibratorio Autopropulsado 10-12 tn [16 h] |  |

| ID | WBS | Activity | Duration | Start | Finish | Predecessors | Total float | Free float | Resources | Filtro |
| --- | --- | --- | --- | --- | --- | --- | --- | --- | --- | --- |
|  | 6 | **RAMPAS** |  | 2025-01-27 | 2025-04-12 |  |  |  |  |  |
|  | 2 | **A3-RA-I-01** |  | 2025-01-27 | 2025-02-13 |  |  |  |  |  |
| A1740 |  | EXCAVACIÓN EN TERRENO NATURAL CON EQUIPO | 9d | 2025-01-27 | 2025-02-04 | A4940, A4930 | 55d | 0d | Excavacion [72] | Excavación |
| A1750 |  | CONFORMACIÓN DE CUERPO DE RAMPA CON MATERIAL PROPIO | 9d | 2025-02-05 | 2025-02-13 | A1740 | 55d | 0d | TRACTOR SOBRE ORUGAS CAT D6D [72 h]; Rodillo Liso Vibratorio Autopropulsado 10-12 tn [72 h] | Relleno |
| A1760 |  | CONFORMACIÓN DE CORONACIÓN DE RAMPA | 9d | 2025-02-05 | 2025-02-13 | A1750 SS | 55d | 51d | Motoniveladora 140K [57.6 h]; Rodillo Liso Vibratorio Autopropulsado 10-12 tn [72 h] | Relleno |
|  | 1 | **A3-RA-D-01** |  | 2025-03-31 | 2025-04-12 |  |  |  |  |  |
| A1710 |  | EXCAVACIÓN EN TERRENO NATURAL CON EQUIPO | 7d | 2025-03-31 | 2025-04-06 | A5280 | 12d | 0d | EXCAVADORA CAT 336 [56 h] | Excavación |
| A1720 |  | CONFORMACIÓN DE CUERPO DE RAMPA CON MATERIAL PROPIO | 6d | 2025-04-07 | 2025-04-12 | A1710 | 12d | 0d | TRACTOR SOBRE ORUGAS CAT D6D [48 h]; Rodillo Liso Vibratorio Autopropulsado 10-12 tn [48 h] | Relleno |
| A1730 |  | CONFORMACIÓN DE CORONACIÓN DE RAMPA | 6d | 2025-04-07 | 2025-04-12 | A1720 SS | 12d |  | Motoniveladora 140K [48 h]; Rodillo Liso Vibratorio Autopropulsado 10-12 tn [48 h] | Relleno |
|  | 2 | **OBRAS DE ARTE** |  | 2024-11-08 | 2025-04-25 |  |  |  |  |  |
|  | 1 | **CAPTACIÓN A3-CP-23-95** |  | 2024-11-26 | 2025-04-12 |  |  |  |  |  |
|  | 1 | **MOVIMIENTO DE TIERRAS** |  | 2024-11-26 | 2025-01-12 |  |  |  |  |  |
| A2770 |  | EXCAVACIÓN ESTRUCTURAL PARA OBRAS DE ARTE | 6d | 2024-11-26 | 2024-12-01 | A4660 SS | 4d | 0d | RETROEXCAVADORA SOBRE LLANTAS 94 HP, 1.25 Y3 [48 h] |  |
| A2780 |  | RELLENO ESTRUCTURAL PARA OBRAS DE ARTE, CON MATERIAL PROPIO | 6d | 2025-01-07 | 2025-01-12 | A2800, A5220 | 29d | 1d | RETROEXCAVADORA SOBRE LLANTAS 94 HP, 1.25 Y3 [12 h]; RODILLO LISO VIBRATORIO MANUAL 10.8 HP 0.8 -1.1 Ton [48 h] |  |
|  | 2 | **OBRAS DE CONCRETO** |  | 2024-12-02 | 2025-01-06 |  |  |  |  |  |
| A2790 |  | CONCRETO f'c=100 kg/cm2 | 3d | 2024-12-02 | 2024-12-04 | A2770 | 14d | 0d | Colocacion de concreto f'c=100 kg/cm2 [13 m3] |  |
| A2810 |  | CONCRETO CICLÓPEO f'c=280 kg/cm2 + 30% P.G. | 3d | 2024-12-05 | 2024-12-07 | A2790 | 14d | 0d | Colocacion de concreto ciclopeo [4 m3] |  |
| A2800 |  | CONCRETO f'c=280 kg/cm2 | 12d | 2024-12-08 | 2024-12-19 | A2820 SS | 19d | 0d | Colocacion de concreto f'c=280 kg/cm2 [115 m3] |  |
| A2820 |  | ENCOFRADO Y DESENCOFRADO RECTO | 13d | 2024-12-08 | 2024-12-20 | A2830 FF | 18d | 0d | Encofrado Recto [94 m3] |  |
| A2830 |  | ACERO DE REFUERZO fy=4200 kg/cm2 | 13d | 2024-12-08 | 2024-12-20 | A2810 | 14d | 0d | armado de acero fy=4200 kg/cm2 [6894 kg] |  |
| A5220 |  | SECADO DE CONCRETO f'c=280 kg/cm2 | 18d | 2024-12-20 | 2025-01-06 | A2800 | 29d | 0d | Encofrado Recto [144 m3] |  |
| A5750 |  | SECADO DE CONCRETO f'c=280 kg/cm2 | 12d | 2024-12-20 | 2024-12-31 | A2800 | 19d | 0d | Encofrado Recto [96 m3] |  |
|  | 3 | **ESTRUCTURAS METALICAS** |  | 2025-01-01 | 2025-01-15 |  |  |  |  |  |
| A2840 |  | COMPUERTA METALICA PLANA DESLIZANTE DE 1.0x1.0m | 3d | 2025-01-01 | 2025-01-03 | A5750 | 19d | 0d | CAMION GRUA 20 TON [24 h] |  |
| A2850 |  | REJILLA DE 1.00x1.00m CON VARILLA DE 1/2" CADA 6,25cm | 3d | 2025-01-04 | 2025-01-06 | A2840 | 19d | 0d | CAMION GRUA 20 TON [24 h] |  |
| A2860 |  | BARANDA DE FIERRO GALVANIZADO 1 1/2" | 3d | 2025-01-07 | 2025-01-09 | A2850 | 19d | 0d | CAMION GRUA 20 TON [24 h] |  |
| A2870 |  | ESCALERA TIPO GATO | 3d | 2025-01-10 | 2025-01-12 | A2860 | 19d | 0d | CAMION GRUA 20 TON [24 h] |  |
| A2880 |  | TAPA METALICA CIRCULAR DN600 MM | 3d | 2025-01-13 | 2025-01-15 | A2870 | 19d | 12d | CAMION GRUA 20 TON [24 h] |  |

| ID | WBS | Activity | Duration | Start | Finish | Predecessors | Total float | Free float | Resources |
| --- | --- | --- | --- | --- | --- | --- | --- | --- | --- |
|  | 4 | **TUBERIAS** |  | 2024-12-02 | 2025-01-24 |  |  |  |  |
| A2890 |  | EXCAVACIÓN ESTRUCTURAL PARA OBRAS DE ARTE (Buzones) | 3d | 2024-12-02 | 2024-12-04 | A2770 | 4d | 0d |  |
| A2900 |  | EXCAVACIÓN DE ZANJA | 25d | 2024-12-05 | 2024-12-29 | A2890 | 4d | 0d | RETROEXCAVADORA SOBRE LLANTAS 94 HP, 1.25 Y3 [200 h] |
| A2920 |  | CAMA DE ARENA | 25d | 2024-12-05 | 2024-12-29 | A2900 SS | 25d | 0d |  |
| A2940 |  | CONCRETO f'c=100 kg/cm2 (Buzones) | 3d | 2024-12-05 | 2024-12-07 | A2900 SS, A2790 | 27d | 13d | Colocacion de concreto f'c=100 kg/cm2 [2 m3] |
| A2990 |  | SUMINISTRO E INSTALACIÓN DE TUBERÍA GRP DN600 mm SN2500 | 25d | 2024-12-05 | 2024-12-29 | A2920 SS | 25d | 0d | Camion grua 20 ton [160 h] |
| A2980 |  | ACERO DE REFUERZO fy=4200 kg/cm2 (Buzones) | 4d | 2024-12-21 | 2024-12-24 | A2940, A2830 | 14d | 0d | armado de acero fy=4200 kg/cm2 [569 kg] |
| A2960 |  | ENCOFRADO Y DESENCOFRADO RECTO | 5d | 2024-12-25 | 2024-12-29 | A2820, A2980 | 14d | 0d | Encofrado Recto [13 m3] |
| A2970 |  | ENCOFRADO Y DESENCOFRADO CURVO | 5d | 2024-12-25 | 2024-12-29 | A2960 SS | 14d | 0d | Encofrado Curvo [25 m3] |
| A2930 |  | RELLENO COMÚN PARA ZANJAS | 26d | 2024-12-30 | 2025-01-24 | A2990 | 25d | 0d | RETROEXCAVADORA SOBRE LLANTAS 94 HP, 1.25 Y3 [208 h] |
| A2950 |  | CONCRETO f'c=280 kg/cm2 (Buzones) | 3d | 2024-12-30 | 2025-01-01 | A2970, A2800 | 23d | 0d | Colocacion de concreto f'c=280 kg/cm2 [11 m3] |
| A2910 |  | RELLENO ESTRUCTURAL PARA OBRAS DE ARTE CON MATERIAL PROPIO (Buzones) | 8d | 2025-01-14 | 2025-01-21 | A2950 FS+12d, A2780, A1200, A3160 | 28d | 3d |  |
|  | 5 | **CANAL** |  | 2024-12-30 | 2025-03-18 |  |  |  |  |
| A3000 |  | EXCAVACIÓN ESTRUCTURAL PARA OBRAS DE ARTE | 6d | 2024-12-30 | 2025-01-04 | A2900 | 4d | 0d |  |
| A3020 |  | COLOCACIÓN DE CONCRETO f'c=100 kg/cm2 | 4d | 2025-01-05 | 2025-01-08 | A2940, A3000 | 4d | 0d | Colocacion de concreto f'c=100 kg/cm2 [38 m3] |
| A3040 |  | ENCOFRADO Y DESENCOFRADO RECTO | 52d | 2025-01-09 | 2025-03-01 | A2970, A3050 SS | 4d | 0d | Encofrado Recto [2032 m3] |
| A3050 |  | ACERO DE REFUERZO fy=4200 kg/cm2 | 28d | 2025-01-09 | 2025-02-05 | A2980, A3020 | 4d | 0d | armado de acero fy=4200 kg/cm2 [14268 kg] |
| A3030 |  | COLOCACIÓN DE CONCRETO f'c=280 kg/cm2 | 53d | 2025-01-11 | 2025-03-04 | A2950 SS, A3040 SS+2d | 11d | 0d | Colocacion de concreto f'c=280 kg/cm2 [164 m3] |
| A3060 |  | JUNTA WATER STOP SIN BULBO 150 mm | 67d | 2025-01-11 | 2025-03-18 | A3030 SS | 20d | 3d | CAMION GRUA 20 TON [536 h] |
| A3010 |  | RELLENO ESTRUCTURAL PARA CANALES, CON MATERIAL PROPIO | 43d | 2025-01-25 | 2025-03-08 | A2910, A2930 | 25d | 21d | Rodillo liso vibratorio 0.80 - 1.10 ton [344 h]; RETROEXCAVADORA SOBRE LLANTAS 94 HP, 1.25 Y3 [86 h] |
|  | 6 | **OBRAS DE DESCARGA** |  | 2025-01-05 | 2025-04-12 |  |  |  |  |
| A3070 |  | EXCAVACIÓN ESTRUCTURAL PARA OBRAS DE ARTE | 10d | 2025-01-05 | 2025-01-14 | A3000 | 30d | 0d | RETROEXCAVADORA SOBRE LLANTAS 94 HP, 1.25 Y3 [80 h] |
| A3090 |  | CONCRETO f'c=100 kg/cm2 | 10d | 2025-01-15 | 2025-01-24 | A3070, A3020 | 30d | 12d | Colocacion de concreto f'c=100 kg/cm2 [2 m3] |
| A3120 |  | ACERO DE REFUERZO fy=4200 kg/cm2 | 10d | 2025-02-06 | 2025-02-15 | A3090, A3050 | 18d | 14d | armado de acero fy=4200 kg/cm2 [78 kg] |
| A3110 |  | ENCOFRADO Y DESENCOFRADO RECTO | 10d | 2025-03-02 | 2025-03-11 | A3120, A3040 | 4d | 0d | Encofrado Recto [24 m3] |
| A3100 |  | CONCRETO f'c=280 kg/cm2 | 10d | 2025-03-12 | 2025-03-21 | A3110, A3030 | 4d | 0d | Colocacion de concreto f'c=280 kg/cm2 [3 m3] |
| A3130 |  | JUNTA WATER STOP SIN BULBO 150 mm | 12d | 2025-03-22 | 2025-04-02 | A3100, A3060 | 17d | 0d | CAMION GRUA 20 TON [96 h] |
| A3080 |  | RELLENO ESTRUCTURAL PARA OBRAS DE ARTE CON MATERIAL PROPIO | 10d | 2025-03-30 | 2025-04-08 | A3100 FS+8d, A3010 | 4d | 0d | RETROEXCAVADORA SOBRE LLANTAS 94 HP, 1.25 Y3 [20 h]; RODILLO LISO VIBRATORIO MANUAL 10.8 HP 0.8 -1.1 Ton [80 h] |
| A3140 |  | COMPUERTA METALICA PLANA DESLIZANTE | 10d | 2025-04-03 | 2025-04-12 | A3100 FS+12d, A3130 | 17d |  | CAMION GRUA 20 TON [80 h] |

| ID | WBS | Activity | Duration | Start | Finish | Predecessors | Total float | Free float | Resources |
| --- | --- | --- | --- | --- | --- | --- | --- | --- | --- |
|  | 2 | **CAPTACIÓN A3-CP-21-05** |  | 2024-11-08 | 2025-03-15 |  |  |  |  |
|  | 1 | **MOVIMIENTO DE TIERRAS** |  | 2024-11-08 | 2025-01-05 |  |  |  |  |
| A3150 |  | EXCAVACIÓN ESTRUCTURAL PARA OBRAS DE ARTE | 4d | 2024-11-08 | 2024-11-11 | A1070 SS+7d, A1015 SS, A1440 SS | 10d | 0d | RETROEXCAVADORA SOBRE LLANTAS 94 HP, 1.25 Y3 [32 h] |
| A3160 |  | RELLENO ESTRUCTURAL PARA OBRAS DE ARTE, CON MATERIAL PROPIO | 23d | 2024-12-14 | 2025-01-05 | A3180 | 36d | 8d | RETROEXCAVADORA SOBRE LLANTAS 94 HP, 1.25 Y3 [46 h]; RODILLO LISO VIBRATORIO MANUAL 10.8 HP 0.8 -1.1 Ton [184 h] |
|  | 2 | **OBRAS DE CONCRETO** |  | 2024-11-12 | 2024-12-25 |  |  |  |  |
| A3170 |  | CONCRETO f'c=100 kg/cm2 | 3d | 2024-11-12 | 2024-11-14 | A3150 | 10d | 0d | Colocacion de concreto f'c=100 kg/cm2 [11 m3] |
| A3190 |  | CONCRETO CICLÓPEO f'c=280 kg/cm2 + 30% P.G. | 3d | 2024-11-15 | 2024-11-17 | A3170 | 10d | 0d | Colocacion de concreto ciclopeo [3 m3] |
| A3180 |  | CONCRETO f'c=280 kg/cm2 | 26d | 2024-11-18 | 2024-12-13 | A3200 SS | 10d | 0d | Colocacion de concreto f'c=280 kg/cm2 [109 m3] |
| A3200 |  | ENCOFRADO Y DESENCOFRADO RECTO | 22d | 2024-11-18 | 2024-12-09 | A3210 SS | 10d | 0d | Encofrado Recto [288 m3] |
| A3210 |  | ACERO DE REFUERZO fy=4200 kg/cm2 | 21d | 2024-11-18 | 2024-12-08 | A3190 | 10d | 0d | armado de acero fy=4200 kg/cm2 [7198 kg] |
| A5230 |  | SECADO DE CONCRETO f'c=280 kg/cm2 | 12d | 2024-12-14 | 2024-12-25 | A3180 | 10d | 0d | Encofrado Recto [96 m3] |
|  | 3 | **ESTRUCTURAS METALICAS** |  | 2024-12-26 | 2025-02-13 |  |  |  |  |
| A3220 |  | COMPUERTA METALICA PLANA DESLIZANTE DE 1.0x1.0m | 10d | 2024-12-26 | 2025-01-04 | A3180, A5230 | 10d | 0d | CAMION GRUA 20 TON [80 h] |
| A3230 |  | REJILLA DE 1.00x1.00m CON VARILLA DE 1/2 CADA 6,25cm | 10d | 2025-01-05 | 2025-01-14 | A3220 | 10d | 0d | CAMION GRUA 20 TON [80 h] |
| A3240 |  | BARANDA DE FIERRO GALVANIZADO 1 1/2" | 10d | 2025-01-15 | 2025-01-24 | A3230 | 10d | 0d | CAMION GRUA 20 TON [80 h] |
| A3250 |  | ESCALERA TIPO GATO | 10d | 2025-01-25 | 2025-02-03 | A3240 | 10d | 0d | CAMION GRUA 20 TON [80 h] |
| A3260 |  | TAPA METALICA CIRCULAR DN600 MM | 10d | 2025-02-04 | 2025-02-13 | A3250 | 10d | 0d | CAMION GRUA 20 TON [80 h] |
|  | 4 | **TUBERIA** |  | 2024-11-12 | 2025-01-12 |  |  |  |  |
| A3270 |  | EXCAVACIÓN ESTRUCTURAL PARA OBRAS DE ARTE (Buzones) | 6d | 2024-11-12 | 2024-11-17 | A3150 | 33d | 0d | EXCAVADORA CAT 336 [48 h] |
| A3280 |  | EXCAVACIÓN DE ZANJA | 6d | 2024-11-18 | 2024-11-23 | A3270 | 113d | 0d | RETROEXCAVADORA SOBRE LLANTAS 94 HP, 1.25 Y3 [48 h] |
| A3330 |  | CONCRETO f'c=100 kg/cm2 (Buzones) | 6d | 2024-11-18 | 2024-11-23 | A3270, A3170 | 33d | 0d | Colocacion de concreto f'c=100 kg/cm2 [1 m3] |
| A3300 |  | CAMA DE ARENA | 6d | 2024-11-24 | 2024-11-29 | A3280 | 113d | 0d | CAMION GRUA 20 TON [48 h] |
| A3380 |  | SUMINISTRO E INSTALACIÓN DE TUBERÍA GRP DN600 mm SN2500 | 5d | 2024-11-30 | 2024-12-04 | A3300 | 113d | 0d | CAMION GRUA 20 TON [40 h] |
| A3310 |  | RELLENO SELECCIONADO PARA ZANJAS CON MATERIAL PROPIO | 6d | 2024-12-05 | 2024-12-10 | A3320 SS | 113d | 81d | RETROEXCAVADORA SOBRE LLANTAS 94 HP, 1.25 Y3 [12 h]; RODILLO LISO VIBRATORIO MANUAL 10.8 HP 0.8 -1.1 Ton [48 h] |
| A3320 |  | RELLENO COMÚN PARA ZANJAS | 6d | 2024-12-05 | 2024-12-10 | A3380 | 113d | 0d | RODILLO LISO VIBRATORIO MANUAL 10.8 HP 0.8 -1.1 Ton [48 h] |
| A3370 |  | ACERO DE REFUERZO fy=4200 kg/cm2 | 5d | 2024-12-09 | 2024-12-13 | A3330, A3210 | 32d | 0d | armado de acero fy=4200 kg/cm2 [218 kg] |
| A3350 |  | ENCOFRADO Y DESENCOFRADO RECTO | 5d | 2024-12-14 | 2024-12-18 | A3370, A3200 | 32d | 0d | Encofrado Recto [5 m3] |
| A3360 |  | ENCOFRADO Y DESENCOFRADO CURVO | 5d | 2024-12-14 | 2024-12-18 | A3350 SS | 32d | 0d | Encofrado Curvo [17 m3] |
| A3340 |  | CONCRETO f'c=280 kg/cm2 (Buzones) | 6d | 2024-12-19 | 2024-12-24 | A3360, A3180 | 63d | 0d | Colocacion de concreto f'c=280 kg/cm2 [7 m3] |
| A5240 |  | SECADO DE CONCRETO f'c=280 kg/cm2 (Buzones) | 12d | 2024-12-25 | 2025-01-05 | A3340 | 80d | 0d | Encofrado Recto [96 m3] |
| A3290 |  | RELLENO ESTRUCTURAL PARA OBRAS DE ARTE CON MATERIAL PROPIO | 7d | 2025-01-06 | 2025-01-12 | A3340, A5240 | 80d | 48d | RODILLO LISO VIBRATORIO MANUAL 10.8 HP 0.8 -1.1 Ton [56 h]; RETROEXCAVADORA SOBRE LLANTAS 94 HP, 1.25 Y3 [14 h] |

| ID | WBS | Activity | Duration | Start | Finish | Predecessors | Total float | Free float | Resources |
| --- | --- | --- | --- | --- | --- | --- | --- | --- | --- |
|  | 5 | **CANALES** |  | 2024-11-18 | 2025-03-15 |  |  |  |  |
| A3390 |  | EXCAVACIÓN ESTRUCTURAL PARA OBRAS DE ARTE | 5d | 2024-11-18 | 2024-11-22 | A3270 | 34d | 1d | RETROEXCAVADORA SOBRE LLANTAS 94 HP, 1.25 Y3 [40 h] |
| A3410 |  | COLOCACIÓN DE CONCRETO f'c=100 kg/cm2 | 24d | 2024-11-24 | 2024-12-17 | A3390, A3330 | 33d | 0d | Colocacion de concreto f'c=100 kg/cm2 [9 m3] |
| A3440 |  | ACERO DE REFUERZO fy=4200 kg/cm2 | 12d | 2024-12-18 | 2024-12-29 | A3410, A3370 | 33d | 1d | armado de acero fy=4200 kg/cm2 [4419 kg] |
| A3430 |  | ENCOFRADO Y DESENCOFRADO | 37d | 2024-12-19 | 2025-01-24 | A3440 SS, A3360 | 32d | 0d | Encofrado Recto [570 m3] |
| A3420 |  | COLOCACIÓN DE CONCRETO f'c=280 kg/cm2 | 24d | 2025-01-25 | 2025-02-17 | A3430, A3340 | 32d | 0d | Colocacion de concreto f'c=280 kg/cm2 [44 m3] |
| A3450 |  | JUNTA WATER STOP SIN BULBO 150 mm | 5d | 2025-01-25 | 2025-01-29 | A3420 SS | 90d |  | CAMION GRUA 20 TON [40 h] |
| A3400 |  | RELLENO ESTRUCTURAL PARA CANALES, CON MATERIAL PROPIO | 14d | 2025-03-02 | 2025-03-15 | A3420 FS+12d, A3290, A3310 | 32d | 28d | RETROEXCAVADORA SOBRE LLANTAS 94 HP, 1.25 Y3 [28 h]; RODILLO LISO VIBRATORIO MANUAL 10.8 HP 0.8 -1.1 Ton [112 h] |
|  | 3 | **RETORNO A3-OA-RE-D-21-55** |  | 2024-11-17 | 2025-02-03 |  |  |  |  |
|  | 1 | **MOVIMIENTO DE TIERRAS** |  | 2024-11-17 | 2025-01-30 |  |  |  |  |
| A3460 |  | EXCAVACIÓN ESTRUCTURAL PARA OBRAS DE ARTE | 3d | 2024-11-17 | 2024-11-19 | A1070 SS+4d, A1015 SS, A4210 | 7d | 0d | RETROEXCAVADORA SOBRE LLANTAS 94 HP, 1.25 Y3 [24 h] |
| A3470 |  | RELLENO ESTRUCTURAL PARA OBRAS DE ARTE, CON MATERIAL PROPIO | 3d | 2025-01-28 | 2025-01-30 | A3490 FS+12d | 11d | 0d | RETROEXCAVADORA SOBRE LLANTAS 94 HP, 1.25 Y3 [6 h]; RODILLO LISO VIBRATORIO MANUAL 10.8 HP 0.8 -1.1 Ton [24 h] |
|  | 2 | **OBRAS DE CONCRETO** |  | 2024-11-20 | 2025-01-15 |  |  |  |  |
| A3480 |  | CONCRETO f'c=100 kg/cm2 | 17d | 2024-11-20 | 2024-12-06 | A3460 | 7d | 0d | Colocacion de concreto f'c=100 kg/cm2 [6 m3] |
| A3500 |  | CONCRETO CICLÓPEO f'c=280 kg/cm2 + 30% P.G. | 15d | 2024-12-07 | 2024-12-21 | A3480 | 7d | 0d | Colocacion de concreto ciclopeo [28 m3] |
| A3510 |  | ENCOFRADO Y DESENCOFRADO | 25d | 2024-12-07 | 2024-12-31 | A3520 SS | 7d | 0d | Encofrado Recto [115 m3] |
| A3520 |  | ACERO DE REFUERZO fy=4200 kg/cm2 | 24d | 2024-12-07 | 2024-12-30 | A3500 SS | 7d | 0d | armado de acero fy=4200 kg/cm2 [8655 kg] |
| A3490 |  | CONCRETO f'c=280 kg/cm2 | 15d | 2025-01-01 | 2025-01-15 | A3510 | 7d | 0d | Colocacion de concreto f'c=280 kg/cm2 [43 m3] |
| A3530 |  | JUNTA WATER STOP SIN BULBO 150 mm | 15d | 2025-01-01 | 2025-01-15 | A3490 SS | 26d | 19d | CAMION GRUA 20 TON [120 h] |
|  | 3 | **ESTRUCTURAS METALICAS** |  | 2025-01-28 | 2025-02-03 |  |  |  |  |
| A3540 |  | COMPUERTA METALICA PLANA DESLIZANTE DE 1.0x1.6 m | 4d | 2025-01-28 | 2025-01-31 | A3490 FS+12d, A2880 | 7d | 0d | CAMION GRUA 20 TON [32 h] |
| A3550 |  | BARANDA DE FIERRO GALVANIZADO 1 1/2" | 3d | 2025-02-01 | 2025-02-03 | A3540 | 7d | 0d | CAMION GRUA 20 TON [24 h] |
|  | 4 | **REPOSICIÓN DE CANALES** |  | 2024-11-19 | 2025-04-25 |  |  |  |  |
|  | 1 | **REPOSICIÓN DE CANAL 1** |  | 2025-01-01 | 2025-04-23 |  |  |  |  |
|  | 1 | **MOVIMIENTO DE TIERRAS** |  | 2025-01-01 | 2025-02-11 |  |  |  |  |
| A3560 |  | DEMOLICIÓN DE ESTRUCTURAS EXISTENTES | 17d | 2025-01-01 | 2025-01-17 | A4390 | 35d | 0d | EXCAVADORA CAT 336 [136 h] |
| A3570 |  | EXCAVACIÓN EN TERRENO NATURAL CON EQUIPO | 36d | 2025-01-07 | 2025-02-11 | A3560 SS+6d, A3760 | 35d | 24d | RETROEXCAVADORA SOBRE LLANTAS 94 HP, 1.25 Y3 [288 h] |
| A3580 |  | RELLENO ESTRUCTURAL PARA OBRAS DE ARTE CON MATERIAL PROPIO | 26d | 2025-01-10 | 2025-02-04 | A4660 SS+45d | 6d | 0d | RETROEXCAVADORA SOBRE LLANTAS 94 HP, 1.25 Y3 [52 h]; RODILLO LISO VIBRATORIO MANUAL 10.8 HP 0.8 -1.1 Ton [208 h] |

| ID | WBS | Activity | Duration | Start | Finish | Predecessors | Total float | Free float | Resources |
| --- | --- | --- | --- | --- | --- | --- | --- | --- | --- |
|  | 2 | **OBRAS DE CONCRETO** |  | 2025-01-31 | 2025-04-23 |  |  |  |  |
| A3600 |  | ACERO DE REFUERZO fy=4200 kg/cm2 | 51d | 2025-01-31 | 2025-03-22 | A3610 SS | 11d | 4d | Camion grua 20 ton [326.4 h] |
| A3610 |  | CONCRETO f'c=100 kg/cm2 | 36d | 2025-01-31 | 2025-03-07 | A3570 SS, A3470 | 11d | 0d | Colocacion de concreto f'c=100 kg/cm2 [122 m3] |
| A3590 |  | ENCOFRADO RECTO | 61d | 2025-02-04 | 2025-04-05 | A3600 SS, A3530, A3550 | 7d | 1d | Encofrado Recto [3708 m3] |
| A3620 |  | CONCRETO f'c=280 kg/cm2 | 54d | 2025-02-05 | 2025-03-30 | A3590 SS, A3580 | 6d | 0d | Colocacion de concreto f'c=280 kg/cm2 [528 m3] |
| A3630 |  | JUNTA WATER STOP 6" | 45d | 2025-02-14 | 2025-03-30 | A3620 SS, A3260 | 10d | 6d | Camion grua 20 ton [288 h] |
| A5730 |  | SECADO DE CONCRETO f'c=280 kg/cm2 | 14d | 2025-03-31 | 2025-04-13 | A3620 | 6d | 0d | Encofrado Recto [112 m3] |
| A3640 |  | MAMPOSTERIA DE PIEDRA, e=20cm, ACABADO CARA VISTA | 6d | 2025-04-03 | 2025-04-08 | A3620, A3130 | 18d | 14d | Camion grua 20 ton [38.4 h] |
| A5740 |  | DESENCOFRADO RECTO | 10d | 2025-04-14 | 2025-04-23 | A5730 | 6d |  | Camion grua 20 ton [64 h] |
|  | 2 | **REPOSICIÓN DE CANAL 3** |  | 2024-11-19 | 2025-04-25 |  |  |  |  |
|  | 1 | **MOVIMIENTO DE TIERRAS** |  | 2024-11-19 | 2025-04-01 |  |  |  |  |
| A3650 |  | DEMOLICIÓN DE ESTRUCTURAS EXISTENTES | 12d | 2024-11-19 | 2024-11-30 | A1440 | 105d | 0d | EXCAVADORA CAT 336 [96 h] |
| A3660 |  | EXCAVACIÓN EN TERRENO NATURAL CON EQUIPO | 18d | 2024-12-01 | 2024-12-18 | A3650 | 105d | 101d | RETROEXCAVADORA SOBRE LLANTAS 94 HP, 1.25 Y3 [144 h] |
| A3670 |  | RELLENO ESTRUCTURAL PARA OBRAS DE ARTE CON MATERIAL PROPIO | 3d | 2025-03-30 | 2025-04-01 | A3660, A3080 SS, A3400 SS | 4d | 0d | RETROEXCAVADORA SOBRE LLANTAS 94 HP, 1.25 Y3 [6 h]; RODILLO LISO VIBRATORIO MANUAL 10.8 HP 0.8 -1.1 Ton [24 h] |
|  | 2 | **OBRAS DE CONCRETO** |  | 2025-04-02 | 2025-04-25 |  |  |  |  |
| A3710 |  | CONCRETO f'c=100 kg/cm2 | 4d | 2025-04-02 | 2025-04-05 | A3670, A3580 | 4d | 0d | Colocacion de concreto f'c=100 kg/cm2 [33 m3] |
| A3680 |  | ENCOFRADO Y DESENCOFRADO PARA REVESTIMIENTO DE CANALES (CERCHAS) | 12d | 2025-04-06 | 2025-04-17 | A3700 SS, A3630, A1760 | 4d | 0d | Encofrado Recto [21 m3] |
| A3690 |  | ENCOFRADO Y DESENCOFRADO RECTO | 12d | 2025-04-06 | 2025-04-17 | A3680 SS | 4d | 0d | Encofrado Recto [630 m3] |
| A3700 |  | MALLA ELECTROSOLDADA DE DN6mm EN CUADRICULA 15x15 cm | 13d | 2025-04-06 | 2025-04-18 | A3710 | 4d | 0d | Camion grua 20 ton [83.2 h] |
| A3730 |  | SELLO DE JUNTA CONSTRUCCIÓN CON MATERIAL ELASTOMÉRICO | 8d | 2025-04-06 | 2025-04-13 | A3680 SS | 16d |  | Camion grua 20 ton [51.2 h] |
| A3720 |  | CONCRETO f'c=280 kg/cm2 | 5d | 2025-04-18 | 2025-04-22 | A3690 | 4d | 0d | Colocacion de concreto f'c=280 kg/cm2 [50 m3] |
| A3740 |  | MAMPOSTERIA DE PIEDRA, e=20cm, ACABADO CARA VISTA | 3d | 2025-04-23 | 2025-04-25 | A3720, A3640 | 4d |  | Camion grua 20 ton [19.2 h] |
|  | 5 | **REPOSICIÓN SIFON INOPERATIVO** |  | 2024-12-10 | 2025-02-25 |  |  |  |  |
| A3750 |  | DEMOLICIÓN DE ESTRUCTURAS EXISTENTES | 4d | 2024-12-10 | 2024-12-13 | A1230, A1880 FF | 48d | 0d | EXCAVADORA CAT 336 [32 h] |
| A3760 |  | EXCAVACIÓN ESTRUCTURAL PARA OBRAS DE ARTE | 11d | 2024-12-14 | 2024-12-24 | A3750 | 48d | 0d | RETROEXCAVADORA SOBRE LLANTAS 94 HP, 1.25 Y3 [88 h] |
| A3770 |  | COLOCACIÓN CAMA DE ARENA | 5d | 2024-12-25 | 2024-12-29 | A3760 | 104d | 0d | Camion grua 20 ton [32 h] |
| A3810 |  | CONCRETO f'c=100 kg/cm2 | 16d | 2024-12-25 | 2025-01-09 | A3760 | 63d | 0d | Colocacion de concreto f'c=100 kg/cm2 [2 m3] |
| A3800 |  | TUBERÍAS DE 14" HDPE SDR21 DN 355mm | 7d | 2024-12-30 | 2025-01-05 | A3770 | 104d | 0d | Camion grua 20 ton [44.8 h] |
| A3850 |  | CODOS HDPE DE 14" DN 355mm | 7d | 2024-12-30 | 2025-01-05 | A3800 SS | 114d |  | Camion grua 20 ton [44.8 h] |
| A3790 |  | RELLENO COMÚN | 10d | 2025-01-06 | 2025-01-15 | A3800 | 104d |  | Camion grua 20 ton [64 h] |
| A3840 |  | ACERO DE REFUERZO fy=4200 kg/cm2 | 13d | 2025-01-10 | 2025-01-22 | A3810 | 63d | 0d | armado de acero fy=4200 kg/cm2 [90 kg] |
| A3830 |  | ENCOFRADO Y DESENCOFRADO RECTO | 13d | 2025-01-23 | 2025-02-04 | A3840 | 63d | 0d | Encofrado Recto [10 m3] |
| A3820 |  | CONCRETO f'c=280 kg/cm2 | 16d | 2025-02-05 | 2025-02-20 | A3830 | 63d | 0d | Colocacion de concreto f'c=280 kg/cm2 [2 m3] |
| A3780 |  | RELLENO ESTRUCTURAL PARA OBRAS DE ARTE CON MATERIAL PROPIO | 5d | 2025-02-21 | 2025-02-25 | A3820 | 63d |  | RETROEXCAVADORA SOBRE LLANTAS 94 HP, 1.25 Y3 [10 h]; RODILLO LISO VIBRATORIO MANUAL 10.8 HP 0.8 -1.1 Ton [40 h] |

| ID | WBS | Activity | Duration | Start | Finish | Predecessors | Total float | Free float | Resources | Filtro |
| --- | --- | --- | --- | --- | --- | --- | --- | --- | --- | --- |
|  | 3 | **ARQUITECTURA Y PAISAJISMO** |  | 2025-01-23 | 2025-04-24 |  |  |  |  |  |
|  | 1 | **OBRAS PRELIMINARES** |  | 2025-01-23 | 2025-04-24 |  |  |  |  |  |
| A3860 |  | MOVILIZACIÓN DE EQUIPOS Y HERRAMIENTAS (ARQUITECTURA Y PAISAJISMO) | 8d | 2025-01-23 | 2025-01-30 | A4420 FS+20d | 5d | 0d |  |  |
| A3870 |  | TRAZO Y REPLANTEO PRELIMINAR | 8d | 2025-01-31 | 2025-02-07 | A3860 | 5d | 0d |  |  |
| A4020 |  | DEMOVILIZACIÓN DE EQUIPOS Y HERRAMIENTAS (ARQUITECTURA Y PAISAJISMO) | 8d | 2025-04-17 | 2025-04-24 | A4010, A3900 | 5d |  |  |  |
|  | 2 | **MOVIMIENTO DE TIERRAS** |  | 2025-02-08 | 2025-02-27 |  |  |  |  |  |
| A3880 |  | EXCAVACIÓN MANUAL PARA INSTALACIÓN DE BORDILLOS Y CIMENTACIONES | 2d | 2025-02-08 | 2025-02-09 | A3870 | 5d | 0d |  |  |
| A3900 |  | ELIMINACION DE MATERIAL EXCEDENTE (DME´S) | 20d | 2025-02-08 | 2025-02-27 | A3880 SS | 53d | 48d |  |  |
| A3890 |  | EXCAVACIÓN PARA MEJORAMIENTO DE SUELO CON TIERRA VEGETAL | 15d | 2025-02-10 | 2025-02-24 | A3880 | 5d | 0d |  |  |
|  | 3 | **PAVIMENTOS, RECUBRIMIENTOS Y BORDILLOS** |  | 2025-02-25 | 2025-03-07 |  |  |  |  |  |
| A3910 |  | PISO DE GRAVILLA | 2d | 2025-02-25 | 2025-02-26 | A3890 | 5d | 0d | Camion grua 20 ton [12.8 h] |  |
| A3920 |  | RECUBRIMIENTO DE PIEDRA DEL LUGAR e=0.05cm | 4d | 2025-02-27 | 2025-03-02 | A3910 | 5d | 0d | Camion grua 20 ton [25.6 h] |  |
| A3930 |  | BORDILLOS DE PIEDRA DEL LUGAR | 5d | 2025-03-03 | 2025-03-07 | A3920 | 5d | 0d | Camion grua 20 ton [32 h] |  |
|  | 4 | **MOBILIARIOS, BARANDAS Y ESCALERAS** |  | 2025-03-08 | 2025-04-14 |  |  |  |  |  |
| A3940 |  | ESCALERA DE CONCRETO SOBRE ENROCADO, CIMENTACION Y ANCLAJE | 10d | 2025-03-08 | 2025-03-17 | A3930 | 5d | 0d | Camion grua 20 ton [64 h] |  |
| A3950 |  | BARANDA DE MADERA EUCALIPTO CON SOGA, INCLUYE CIMENTACIÓN | 4d | 2025-03-18 | 2025-03-21 | A3940 | 5d | 0d | Camion grua 20 ton [25.6 h] |  |
| A3960 |  | TACHOS DE BASURA, INCLUYE CIMENTACIÓN | 3d | 2025-03-22 | 2025-03-24 | A3950 | 5d | 0d | Camion grua 20 ton [19.2 h] |  |
| A3970 |  | BANCAS DE CONCRETO, INCLUYE CIMENTACIÓN | 10d | 2025-03-25 | 2025-04-03 | A3960 | 5d | 0d | Camion grua 20 ton [64 h] |  |
| A3980 |  | POSTES DE ILUMINACIÓN, INCLUYE LUMINARIA Y CIMENTACIÓN | 5d | 2025-04-04 | 2025-04-08 | A3970 | 5d | 0d | Camion grua 20 ton [32 h] |  |
| A3990 |  | SEÑALETICA INFORMATIVA | 3d | 2025-04-09 | 2025-04-11 | A3980 | 5d | 0d | Camion grua 20 ton [19.2 h] |  |
| A4000 |  | BOLARDOS DE PIEDRA | 3d | 2025-04-12 | 2025-04-14 | A3990 | 5d | 0d | Camion grua 20 ton [19.2 h] |  |
|  | 5 | **INSTALACIÓN DE ALCORQUES** |  | 2025-04-15 | 2025-04-16 |  |  |  |  |  |
| A4010 |  | ALCORQUES DE PIEDRA DE CANTO RODADO PARA ARBOLES | 2d | 2025-04-15 | 2025-04-16 | A4000 | 5d | 0d | Camion grua 20 ton [12.8 h] |  |
|  | 4 | **PROGRAMA DE CIERRE DE OBRA** |  | 2024-11-06 | 2025-04-22 |  |  |  |  |  |
| A1770 |  | ACONDICIONAMIENTO DE DEPOSITOS DE MATERIALES EXCEDENTES (DME) | 160d | 2024-11-06 | 2025-04-14 | A1220 SS | 7d | 0d | EXCAVADORA CAT 336 [320 h]; TRACTOR SOBRE ORUGAS CAT D6D [1280 h] | Excavación |
| A1780 |  | RESTAURACIÓN DE ÁREAS DE INSTALACIONES PROVISIONALES | 8d | 2025-04-15 | 2025-04-22 | A1770 | 7d |  | TRACTOR SOBRE ORUGAS CAT D6D [64 h] |  |
